# Subproject HTML-SAMPLE

Schedule from MS Project, 2007-07-09 to 2007-09-12.

## Calendars

- Our Global Company: Mon-Fri 08:00-12:00, 13:00-17:00; Sat-Sun off. Exceptions (off unless hours are given): 2007-09-03 (Labor Day).

## Resources

| Resource | Notes |
| --- | --- |
| Writer 1 | Software expert. |
| Editor 1 | Style expert. |
| Printer 1 | Needs setup time. |
| Artist 1 | Callouts, custom figures. |
| Project Manager 1 | Specializes in short projects. |
| Staff Assistant 1 | Competent under pressure. |
| Account Rep 1 | Very creative. |
| Publisher 1 | Lots of patience. |
| Subject Matter Expert 1 | From TC Agency. |

## Schedule

| ID | WBS | Task | Type | Duration | Start | Finish | Predecessors | Total slack | Constraint | Resources | Work |
| --- | --- | --- | --- | --- | --- | --- | --- | --- | --- | --- | --- |
| 1 | Subproject 2- 1 | **HTML Training Manual** |  | 46.17d | 2007-07-09 | 2007-09-12 |  | 0d |  |  | 476h |
| 2 | Subproject 2- 1.1 | Start Book | milestone | 0d | 2007-07-09 | 2007-07-09 |  | 0d | start no earlier than 2007-07-09 | Project Manager 1 |  |
| 3 | Subproject 2- 1.2 | **Research Phase** |  | 6.5d | 2007-07-09 | 2007-07-17 |  | 0d |  |  | 60h |
| 4 | Subproject 2- 1.2.1 | Interview Subject Matter Expert |  | 1d | 2007-07-09 | 2007-07-09 | 2 | 0d |  | Writer 1; Subject Matter Expert 1 | 16h |
| 5 | Subproject 2- 1.2.2 | Investigate the software |  | 3.5d | 2007-07-10 | 2007-07-13 | 4 | 0d |  | Subject Matter Expert 1 | 28h |
| 6 | Subproject 2- 1.2.3 | Search the Web |  | 2d | 2007-07-13 | 2007-07-17 | 5 | 0d |  | Writer 1 | 16h |
| 7 | Subproject 2- 1.3 | **Outline Phase** |  | 7d | 2007-07-17 | 2007-07-26 |  | 0d |  |  | 96h |
| 8 | Subproject 2- 1.3.1 | Create outline |  | 3d | 2007-07-17 | 2007-07-20 | 6 | 0d |  | Writer 1 | 24h |
| 9 | Subproject 2- 1.3.2 | Present to publisher |  | 1d | 2007-07-20 | 2007-07-23 | 8 | 0d |  | Writer 1; Staff Assistant 1 | 16h |
| 10 | Subproject 2- 1.3.3 | Review with Subject Matter Expert |  | 2d | 2007-07-23 | 2007-07-25 | 9 | 33.67d |  | Writer 1; Subject Matter Expert 1 | 32h |
| 11 | Subproject 2- 1.3.4 | Revise outline |  | 3d | 2007-07-23 | 2007-07-26 | 9 | 0d |  | Writer 1 | 24h |
| 12 | Subproject 2- 1.4 | **Development Phase** |  | 26d | 2007-07-26 | 2007-08-31 |  | 0d |  |  | 208h |
| 13 | Subproject 2- 1.4.1 | Write content |  | 22d | 2007-07-26 | 2007-08-27 | 11 | 0d |  | Writer 1 | 176h |
| 14 | Subproject 2- 1.4.2 | Add graphics |  | 4d | 2007-08-27 | 2007-08-31 | 13 | 0d |  | Writer 1 | 32h |
| 15 | Subproject 2- 1.5 | **Edit Phase** |  | 2d | 2007-08-31 | 2007-09-05 |  | 0d |  |  | 40h |
| 16 | Subproject 2- 1.5.1 | Check grammar, spelling, and proofread |  | 2d | 2007-08-31 | 2007-09-04 | 14 | 0d |  | Writer 1; Editor 1 | 32h |
| 17 | Subproject 2- 1.5.2 | Check for technical accuracy |  | 1d | 2007-09-04 | 2007-09-05 | 16 | 0d |  | Writer 1 | 8h |
| 18 | Subproject 2- 1.6 | **Review Phase** |  | 1.67d | 2007-09-05 | 2007-09-07 |  | 0d |  |  | 32h |
| 19 | Subproject 2- 1.6.1 | Approve editing changes |  | 1d | 2007-09-05 | 2007-09-06 | 17 | 0d |  | Writer 1; Subject Matter Expert 1 | 16h |
| 20 | Subproject 2- 1.6.2 | Meet with editor |  | 0.67d | 2007-09-06 | 2007-09-07 | 19 | 0d |  | Subject Matter Expert 1; Writer 1; Editor 1 | 16h |
| 21 | Subproject 2- 1.7 | **Print Phase** |  | 3d | 2007-09-07 | 2007-09-12 |  | 0d |  |  | 40h |
| 22 | Subproject 2- 1.7.1 | Print proof |  | 1d | 2007-09-07 | 2007-09-10 | 20 | 0d |  | Writer 1; Printer 1 | 16h |
| 23 | Subproject 2- 1.7.2 | Review proof |  | 1d | 2007-09-10 | 2007-09-11 | 22 | 0d |  | Printer 1; Writer 1 | 16h |
| 24 | Subproject 2- 1.7.3 | Print final |  | 1d | 2007-09-11 | 2007-09-12 | 23 | 0d |  | Printer 1 | 8h |
| 25 | Subproject 2- 1.8 | Book Complete | milestone | 0d | 2007-09-12 | 2007-09-12 | 24, 13 | 0d |  | Project Manager 1 |  |
