# Unix Training Manual

Schedule from MS Project, 2007-07-09 to 2007-09-25, costs in $, A marks actual dates.

## Calendars

- Our Global Company: Mon-Fri 08:00-12:00, 13:00-17:00; Sat-Sun off. Exceptions (off unless hours are given): 2007-09-03 (Labor Day).

## Resources

| Resource | Group | Unit | Rate | Notes |
| --- | --- | --- | --- | --- |
| Writer 1 |  |  | 45 |  |
| Editor 1 |  |  | 17 |  |
| Printer 1 |  |  | 10 |  |
| Artist 1 |  |  | 25 |  |
| Project Manager 1 |  |  | 60 |  |
| Staff Assistant 1 |  |  | 12 |  |
| Publisher 1 |  |  | 150 |  |
| Subject Matter Expert 1 | External |  | 75 |  |
| Plain paper |  | pages | 5 | For printing the proof. |

## Schedule

| ID | WBS | Task | Type | Duration | Start | Finish | Predecessors | Complete | Remaining | Total slack | Free slack | Resources | Work | Actual work | Cost | Actual cost |
| --- | --- | --- | --- | --- | --- | --- | --- | --- | --- | --- | --- | --- | --- | --- | --- | --- |
| 1 | 1 | **Training Manual** |  | 55.17d | 2007-07-09 A | 2007-09-25 |  | 5% | 52.51d | 0d |  |  | 584h | 34.4h | 24,021 | 1,569.6 |
| 2 | 1.1 | Start Book | milestone | 0d | 2007-07-09 A | 2007-07-09 A |  | 100% |  |  |  | Project Manager 1; Writer 1 |  |  |  |  |
| 3 | 1.2 | **Research Phase** |  | 7d | 2007-07-09 A | 2007-07-17 |  | 39% | 4.3d | 0d |  |  | 88h | 34.4h | 3,792 | 1,569.6 |
| 4 | 1.2.1 | Interview Subject Matter Expert |  | 1d | 2007-07-09 A | 2007-07-09 | 2 | 50% | 0.5d | 2.2d | 0d | Project Manager 1; Writer 1; Subject Matter Expert 1 | 24h | 12h | 1,440 | 720 |
| 5 | 1.2.2 | Investigate Unix |  | 4d | 2007-07-10 A | 2007-07-13 | 4 | 40% | 2.4d | 0.6d | 0d | Writer 1 | 32h | 12.8h | 1,440 | 576 |
| 6 | 1.2.3 | Search the Web |  | 2d | 2007-07-16 A | 2007-07-17 | 5 | 30% | 1.4d | 0d |  | Writer 1; Staff Assistant 1 | 32h | 9.6h | 912 | 273.6 |
| 7 | 1.3 | **Outline Phase** |  | 10.17d | 2007-07-17 A | 2007-07-31 |  |  | 10.17d | 0d |  |  | 96h |  | 5,320 |  |
| 8 | 1.3.1 | Create outline |  | 3d | 2007-07-18 | 2007-07-20 | 6 |  |  | 0d |  | Writer 1 | 24h |  | 1,080 |  |
| 9 | 1.3.2 | Present to publisher |  | 0.67d | 2007-07-23 | 2007-07-23 | 8 |  |  | 0d |  | Writer 1; Project Manager 1; Publisher 1 | 16h |  | 1,360 |  |
| 10 | 1.3.3 | Review with Subject Matter Expert |  | 1.5d | 2007-07-17 A | 2007-07-25 | 9 |  | 1.5d | 0d |  | Writer 1; Subject Matter Expert 1 | 24h |  | 1,440 |  |
| 11 | 1.3.4 | Revise outline |  | 4d | 2007-07-25 | 2007-07-31 | 10 |  |  | 0d |  | Writer 1 | 32h |  | 1,440 |  |
| 12 | 1.4 | **Development Phase** |  | 32d | 2007-07-31 | 2007-09-14 |  |  |  | 0d |  |  | 296h |  | 11,200 |  |
| 13 | 1.4.1 | Write content |  | 27d | 2007-07-31 | 2007-09-07 | 11 |  |  | 0d |  | Writer 1 | 216h |  | 9,720 |  |
| 14 | 1.4.2 | Add graphics |  | 5d | 2007-09-07 | 2007-09-14 | 13 |  |  | 0d |  | Artist 1; Staff Assistant 1 | 80h |  | 1,480 |  |
| 15 | 1.5 | **Edit Phase** |  | 2d | 2007-09-14 | 2007-09-18 |  |  |  | 0d |  |  | 24h |  | 872 |  |
| 16 | 1.5.1 | Check grammar, spelling, and proofread |  | 1d | 2007-09-14 | 2007-09-17 | 14 |  |  | 0d |  | Editor 1 | 8h |  | 136 |  |
| 17 | 1.5.2 | Check for technical accuracy |  | 1d | 2007-09-17 | 2007-09-18 | 16FF |  |  | 0d |  | Editor 1; Subject Matter Expert 1 | 16h |  | 736 |  |
| 18 | 1.6 | **Review Phase** |  | 2d | 2007-09-18 | 2007-09-20 |  |  |  | 0d |  |  | 24h |  | 856 |  |
| 19 | 1.6.1 | Approve editing changes |  | 1d | 2007-09-18 | 2007-09-19 | 17 |  |  | 0d |  | Writer 1 | 8h |  | 360 |  |
| 20 | 1.6.2 | Meet with editor |  | 1d | 2007-09-19 | 2007-09-20 | 19 |  |  | 0d |  | Editor 1; Writer 1 | 16h |  | 496 |  |
| 21 | 1.7 | **Print Phase** |  | 3d | 2007-09-20 | 2007-09-25 |  |  |  | 0d |  |  | 40h |  | 1,141 |  |
| 22 | 1.7.1 | Print proof |  | 1d | 2007-09-20 | 2007-09-21 | 20 |  |  | 0d |  | Printer 1; Plain paper [1 pages] | 8h |  | 85 |  |
| 23 | 1.7.2 | Review proof |  | 1d | 2007-09-21 | 2007-09-24 | 22 |  |  | 0d |  | Writer 1; Editor 1; Project Manager 1 | 24h |  | 976 |  |
| 24 | 1.7.3 | Print final |  | 1d | 2007-09-24 | 2007-09-25 | 23 |  |  | 0d |  | Printer 1 | 8h |  | 80 |  |
| 25 | 1.8 | Book Complete |  | 1d | 2007-09-24 | 2007-09-25 | 24FF |  |  | 0d |  | Project Manager 1; Writer 1 | 16h |  | 840 |  |
